# dp

Schedule from MS Project, 2018-05-01 to 2021-10-06, costs in $.
Microsoft

## Calendars

- Holiday: Mon-Fri 08:00-12:00, 13:00-17:00; Sat-Sun off. Exceptions (off unless hours are given): 2018-05-28 (H), 2018-07-04 (H), 2018-09-03 (H), 2018-10-08 (H), 2018-11-12 (H), 2018-11-22 to 2018-11-23 (H), 2018-12-24 to 2018-12-25 (H), 2019-01-01 (H), 2019-01-21 (H), 2019-02-18 (H), 2019-05-27 (H).

## Resources

| Resource | Group | Rate |
| --- | --- | --- |
| Cable Pullers | CA-D |  |
| Carp | PE | 96.69 |
| CAS | FES | 110.31 |
| CA-Technician | CA-D | 110 |
| Central Shops | CS | 149.44 |
| Cont Carpenters | PE | 100 |
| Cont Electricians | PE | 100 |
| Contract |  | 100 |
| Designer | CA-D |  |
| Elect Eng | FES | 142 |
| Electrician | PE | 97 |
| Health Physics |  |  |
| HVAC Techs | PE | 123 |
| Liaison Eng |  |  |
| Line Crew | PE | 123 |
| Mech Tech | FES | 110 |
| Mech Eng | FES | 141.77 |
| PE | PE | 122.54 |
| PE Plumb | PE | 123 |
| Purch |  | 1 |
| Purchase Medium |  | 1 |
| Rigger | PE | 97 |
| Steam Shop | PE |  |
| Survey | FES | 110 |
| Water Systems | FES | 110 |
| Welder | CS | 149 |
| Magnet Div |  |  |
| Cryo tech |  |  |

## Schedule

| ID | WBS | Task | Type | Duration | Start | Finish | Predecessors | Total slack | Free slack | Constraint | Resources | Work | Cost |
| --- | --- | --- | --- | --- | --- | --- | --- | --- | --- | --- | --- | --- | --- |
| 1 | 1 | RHIC Run 19 |  | 115d | 2019-01-02 | 2019-06-14 |  | 599d |  | finish no earlier than 2019-06-14 |  |  |  |
| 2 | 2 | RHIC Run 20 |  | 119d | 2020-01-01 | 2020-06-15 |  | 338d |  | finish no earlier than 2020-06-15 |  |  |  |
| 3 | 3 | RHIC Run 21 |  | 107d | 2021-01-01 | 2021-05-31 |  | 88d |  | finish no earlier than 2021-05-31 |  |  |  |
| 4 | 4 | H-Cal Steel Ready for Cryostat Installation | milestone | 0d | 2021-05-03 | 2021-05-03 |  | 109d |  | start no earlier than 2021-05-03 |  |  |  |
| 5 | 5 | Magnet Platform Ready for Installations in 1008-AH | milestone | 0d | 2021-10-01 | 2021-10-01 |  | 0d |  | start no earlier than 2021-10-01 |  |  |  |
| 7 | 6 | **Investigate and repair instrumentation issues found during the superconducting solenoid operating current test. Planning** |  | 25.5d | 2019-03-01 | 2019-04-05 |  | 616d |  |  |  | 344h | 26,537.8 |
| 8 | 6.1 | Disconnect Cryo & Instrumentation from Valve box and Platform |  | 1d | 2019-03-01 | 2019-03-01 |  | 651.5d | 0d | start no earlier than 2019-03-01 | Cryo tech; Liaison Eng | 12h |  |
| 9 | 6.2 | Disconnect Valve Box from Magnet at New-Doghouse |  | 5d | 2019-03-04 | 2019-03-08 | 8 | 651.5d | 0d |  | Magnet Div; Liaison Eng | 44h |  |
| 10 | 6.3 | Set-up Valve Box Storage Base |  | 1.5d | 2019-03-11 | 2019-03-12 | 9 | 651.5d | 0d |  | Rigger; Liaison Eng | 16h | 1,164 |
| 11 | 6.4 | Move Valve Box to Storage Base |  | 1.5d | 2019-03-12 | 2019-03-13 | 10 | 651.5d | 0d |  | Mech Tech; Rigger; Carp; Magnet Div; Liaison Eng | 36h | 2,430.76 |
| 12 | 6.5 | Remove Valve Box Platform (leave lower section to access Doghouses) |  | 4.5d | 2019-03-14 | 2019-03-20 | 11 | 651.5d | 0d |  | Carp; Electrician; Rigger; Liaison Eng | 72h | 6,591.04 |
| 13 | 6.6 | Open Steel Roof to Allow Mag Div Access to Old-Doghouse |  | 12d | 2019-03-20 | 2019-04-05 | 12 | 602.5d | 0d |  | Mech Tech; Rigger; Liaison Eng | 164h | 16,352 |
| 14 | 7 | Check the voltage taps and strain gauge boards at the “dog house” location closest to the solenoid cryostat and between the “2nd” dog house and the cable termination valve box. Check the temperature sensors wiring in the dog house for the sensors that wer |  | 20d | 2019-04-05 | 2019-05-03 | 13 | 602.5d | 0d |  |  |  |  |
| 15 | 8 | Check the temperature sensors wiring in the dog house for the sensors that were not working. |  | 1d | 2018-05-01 | 2018-05-01 |  | 883d |  |  |  |  |  |
| 16 | 9 | After repairs, store solenoid cryostat in B912 in a safe preservation state until the base assembly in B1008 is ready. Seal insulating vacuum volume and backfill with dry Nitrogen gas. |  | 1d | 2018-05-01 | 2018-05-01 |  | 883d |  |  |  |  |  |
| 17 | 10 | Preparation for shipping: disconnect solenoid power, instrumentation, and cryogenic system instrumentation and piping. Design and install cribbing for transport trailer (remove and recycle cribbing after the move). |  | 1d | 2018-05-01 | 2018-05-01 |  | 883d |  |  |  |  |  |
| 18 | 11 | **Preparation for shipping: Interface with magnet division for the removal of the valve box/cable termination cryostat and installation of shipping support fixtures for the interconnecting cryogenic “dog houses”. Install shipping fixtures, seal cryostat ins** |  | 5d | 2019-05-03 | 2019-05-10 |  | 602.5d |  |  |  | 80h | 5,744 |
| 19 | 11.1 | Install Valve Box extension Support |  | 1d | 2019-05-03 | 2019-05-06 | 14 | 602.5d | 0d |  | Liaison Eng; Mech Tech; Rigger | 20h | 1,656 |
| 20 | 11.2 | Install Shipping Fixtures |  | 1d | 2019-05-06 | 2019-05-07 | 19 | 602.5d | 0d |  | Magnet Div | 8h |  |
| 21 | 11.3 | Move Mag Cryostat into yellow shipping frame |  | 3d | 2019-05-07 | 2019-05-10 | 20 | 602.5d | 0d |  | Liaison Eng; Mech Tech; Rigger | 52h | 4,088 |
| 22 | 12 | **Preparation for shipping: remove and recycle steel yoke assembly, scaffolding and stairways, power panels, cables, cable tray, cryogenic piping, etc. Clear 912 test areas.** |  | 25d | 2019-05-10 | 2019-06-17 |  | 602.5d |  |  |  | 736h | 72,067.68 |
| 23 | 12.1 | Remove all Return Steel & remaining Lower Platform |  | 25d | 2019-05-10 | 2019-06-17 | 21 | 602.5d |  |  | Liaison Eng; Mech Tech; Rigger [300%]; Carp; PE | 736h | 72,067.68 |
| 24 | 13 | **Transport of the solenoid cryostat from B912 to B1008 and installation of the solenoid cryostat onto the sPHENIX detector base assembly in B1008 directly from the trailer.** |  | 4d | 2021-05-03 | 2021-05-06 |  | 105d |  |  |  | 48h | 3,984 |
| 25 | 13.1 | Move Mag Cryostat from B912 to 1008-AH & place on H-Cal Steel Base |  | 4d | 2021-05-03 | 2021-05-06 | 4 | 105d | 0d |  | Liaison Eng; Mech Tech; Rigger | 48h | 3,984 |

| ID | WBS | Task | Duration | Start | Finish | Predecessors | Total slack | Resources | Work | Cost |
| --- | --- | --- | --- | --- | --- | --- | --- | --- | --- | --- |
| 26 | 14 | **Installation and alignment support including survey support for the attachment and alignment of the solenoid cryostat to the steel flux return (HCal steel) base assembly.** | 4d | 2021-05-07 | 2021-05-12 |  | 105d |  | 36h | 3,520 |
| 27 | 14.1 | Survey Mag Supports | 4d | 2021-05-07 | 2021-05-12 | 25 | 105d | Liaison Eng; Survey | 36h | 3,520 |
| 28 | 15 | **After installation, interface with and support the magnet division for the re-installation of the valve box/cable termination cryostat and removal of shipping support fixtures.** | 4d | 2021-10-01 | 2021-10-06 |  | 0d |  | 80h | 6,517.52 |
| 29 | 15.1 | Move Valve Box from B912 to 1008-AH & into place on Platform | 4d | 2021-10-01 | 2021-10-06 | 5 | 0d | Liaison Eng; Mech Tech; Magnet Div; Rigger; Survey; Carp | 80h | 6,517.52 |
| 30 | 16 | Complete experimental area safety reviews and rigging, transport, and installation plans and safety reviews. | 1d | 2018-05-01 | 2018-05-01 |  | 883d |  |  |  |
| 31 | 17 | Prepare and present at design reviews, system interface reviews, and production readiness reviews. Provide and update cost and schedule information to the project control team. | 1d | 2018-05-01 | 2018-05-01 |  | 883d |  |  |  |
